# Spring 2004 Update v0

Schedule from MS Project, 2004-07-19 to 2004-10-01.
MIT

## Calendars

- Standard: Mon-Fri 08:00-12:00, 13:00-17:00; Sat-Sun off. Exceptions (off unless hours are given): 2004-07-24 08:00-12:00, 13:00-17:00, 2004-08-07 to 2004-08-08 08:00-12:00, 13:00-17:00, 2004-08-14 to 2004-08-15 08:00-12:00, 13:00-17:00, 2004-08-21 08:00-12:00, 13:00-17:00, 2004-09-04 08:00-12:00, 13:00-17:00, 2004-09-18 to 2004-09-19 08:00-12:00, 13:00-17:00, 2004-09-25 to 2004-09-26 08:00-12:00, 13:00-17:00.

## Resources

| Resource |
| --- |
| R3-Adm |
| HRP |
| FSS |
| ALL |
| CAO |
| BPO |
| AD |
| AD-HR-Pay |
| ASST |

## Schedule

| ID | Task | Type | Duration | Start | Finish | Predecessors | Baseline start | Baseline finish | Baseline duration | Total slack | Free slack | Constraint | Resources | Work |
| --- | --- | --- | --- | --- | --- | --- | --- | --- | --- | --- | --- | --- | --- | --- |
| 1 | Target Patch Levels Determined | milestone | 0d | 2004-07-19 | 2004-07-19 |  | 2003-02-10 | 2003-02-10 | 0d | 66d |  | start no earlier than 2004-07-19 | R3-Adm |  |
| 2 | Operating System Upgrade: SF3 & SF8 |  | 1d | 2004-07-21 | 2004-07-21 |  |  |  |  | 63d |  | start no earlier than 2004-07-21 | ASST | 8h |
| 3 | Infrastructure Evaluations |  | 4d | 2004-07-28 | 2004-08-02 |  | 2003-02-17 | 2003-02-21 | 5d | 54d |  | start no earlier than 2004-07-28 | R3-Adm | 32h |
| 4 | Operating System Upgrade: SF6, SF7, SH1, SH2, SF2 |  | 1d | 2004-08-04 | 2004-08-04 |  |  |  |  | 48d | 0d | start no earlier than 2004-08-04 | ASST | 8h |
| 5 | Update Patch levels / Re-apply OSS notes in SF3 |  | 3d | 2004-08-05 | 2004-08-07 | 4 | 2003-02-24 | 2003-02-24 | 0d | 48d | 0d | start no earlier than 2004-08-03 | R3-Adm | 24h |
| 6 | Execute SF3 Action Log |  | 1d | 2004-08-08 | 2004-08-08 | 5 | 2003-03-25 | 2003-03-26 | 2d | 48d |  | start no earlier than 2003-03-18 | AD | 8h |
| 7 | Development Freeze |  | 4d | 2004-08-06 | 2004-08-09 |  | 2003-03-20 | 2003-03-25 | 4d | 47d |  | finish no earlier than 2004-08-09 | ALL | 32h |
| 8 | Update Patch Levels in SF2 and SF8 |  | 3d | 2004-08-07 | 2004-08-09 |  | 2003-03-20 | 2003-03-20 | 1d | 47d |  | start no earlier than 2004-08-07 | R3-Adm | 24h |
| 9 | Snapshot of PS1 for SF6 refresh | milestone | 0d | 2004-08-15 | 2004-08-15 |  | 2003-03-10 | 2003-03-10 | 0d | 42d |  | start no earlier than 2004-08-15 | R3-Adm |  |
| 10 | Execute SF2 & SF8 Action Logs |  | 1d | 2004-08-10 | 2004-08-10 |  | 2003-03-21 | 2003-03-24 | 2d | 39d | 0d | start no earlier than 2004-08-10 | AD | 8h |
| 11 | SF2 & SF8 Unit testing |  | 7d | 2004-08-11 | 2004-08-17 | 10 | 2003-03-21 | 2003-03-24 | 2d | 39d |  | finish no earlier than 2004-08-16 | AD | 56h |
| 12 | Operating System Upgrade: SF5 |  | 1d | 2004-08-17 | 2004-08-17 |  |  |  |  | 39d |  | start no earlier than 2004-08-17 | ASST | 8h |
| 13 | SF6 changed from Education & Practice to Integration Test | milestone | 0d | 2004-08-12 | 2004-08-12 |  |  |  |  | 45d |  | start no earlier than 2004-08-12 | ALL |  |
| 14 | SF6 Unavailable for general use |  | 40d | 2004-08-17 | 2004-10-01 |  | 2003-03-20 | 2003-05-02 | 32d | 0d |  | start no earlier than 2004-08-17 |  |  |
| 15 | SF6 Refresh & Update Activities |  | 7d | 2004-08-13 | 2004-08-19 |  | 2003-03-20 | 2003-03-20 | 1d | 35d | 1d | start no earlier than 2004-08-13 | R3-Adm | 56h |
| 16 | Execute SF6 Action Log |  | 2d | 2004-08-21 | 2004-08-23 | 15 |  |  |  | 34d |  | start no earlier than 2004-08-21 | AD | 16h |
| 17 | Integration Test Preparations in SF6 |  | 3d | 2004-08-23 | 2004-08-25 |  |  |  |  | 19.5d | 0d | start no earlier than 2004-08-23 | AD | 24h |
| 18 | Integration Test Execution & Resolution in SF6 |  | 12d | 2004-08-26 | 2004-09-09 | 17 |  |  |  | 19.5d | 2d | start no earlier than 2004-08-26 | ALL | 96h |
| 19 | Operating System Upgrade: PS1 Production |  | 1d | 2004-09-04 | 2004-09-04 |  |  |  |  | 23d | 11d | start no earlier than 2004-09-04 | ASST | 8h |
| 20 | Meeting to determine Go / No Go (SAPbiz, AdminComp reps) |  | 0.5d | 2004-09-14 | 2004-09-14 | 18 |  |  |  | 17.5d |  | start no earlier than 2004-09-14 |  |  |
| 21 | Update Patch Levels in SF7 (Training) |  | 1d | 2004-09-19 | 2004-09-19 | 19, 20 |  |  |  | 12d |  | start no earlier than 2004-09-19 |  |  |
| 22 | Update Patch Levels in PS1 |  | 1d | 2004-09-18 | 2004-09-18 |  |  |  |  | 11.5d | 0d | finish no earlier than 2004-09-18 | R3-Adm; AD | 16h |
| 23 | Execute PS1 Validation |  | 1.5d | 2004-09-19 | 2004-09-20 | 22 |  |  |  | 11.5d |  | start no earlier than 2004-09-19 | AD; BPO | 24h |
| 24 | PS1 Available to MIT Community | milestone | 0d | 2004-09-20 | 2004-09-20 |  |  |  |  | 12d | 2d | start no earlier than 2004-09-20 |  |  |
| 25 | Snapshot of PS1 for SF5 refresh | milestone | 0d | 2004-09-22 | 2004-09-22 | 24 |  |  |  | 10d |  | start no earlier than 2004-09-22 | R3-Adm |  |
| 26 | Update Patch Levels in SH1 & SH2 |  | 4d | 2004-09-25 | 2004-09-28 | 25 |  |  |  | 2d | 0d | finish no earlier than 2004-09-28 |  |  |
| 27 | Execute SH1 & SH2 Action Log |  | 1d | 2004-09-29 | 2004-09-29 | 26 |  |  |  | 2d |  | start no earlier than 2003-05-14 |  |  |
| 28 | HR data scramble in SF6 |  | 1d | 2004-09-29 | 2004-09-29 |  |  |  |  | 2d |  | start no earlier than 2004-09-29 | AD | 8h |
| 29 | Refresh SF5 |  | 3d | 2004-09-28 | 2004-09-30 |  |  |  |  | 0d |  | start no earlier than 2004-09-28 |  |  |
| 30 | Execute SF5 Action Log |  | 1d | 2004-10-01 | 2004-10-01 | 29 |  |  |  | 0d |  | start no earlier than 2003-05-14 |  |  |

Notes:
- 5: Only an end date was given by R3-Adm - BC 3/3/03
- 9: This date is a place holder. The actual date may vary. The monthly close process must be completed prior to taking the snapshot.
- 28: Still need to determine if HR data scrambling is necessary in SF6 before non-HR testing starts 8/30 --KL 7/9/04.
